Schedule from Planner, 2013-09-02 to 2016-06-01.

## Calendars

- Default: Mon-Fri 08:00-12:00, 13:00-17:00; Sat-Sun off.

## Schedule

| ID | Task | Type | Duration | Start | Finish | Predecessors | Constraint | Work |
| --- | --- | --- | --- | --- | --- | --- | --- | --- |
| 1 | Supercam Instrument Validation |  |  | 2013-09-02 | 2013-10-25 |  |  | 320h |
| 2 | Supercam Instrument Readiness Review | milestone | 0d | 2013-10-25 | 2013-10-25 | 1 |  |  |
| 3 | First Supercam Observing Run at HHT |  |  | 2013-11-01 | 2013-12-05 |  | must start on 2013-11-01 | 200h |
| 4 | First run data processing |  |  | 2013-12-06 | 2014-02-27 | 3 |  | 480h |
| 5 | Second Supercam Observing Run at HHT |  |  | 2014-03-03 | 2014-04-04 | 4 | must start on 2014-03-01 | 200h |
| 6 | Second run data processing |  |  | 2014-04-07 | 2014-09-04 | 5 |  | 866.75h |
| 7 | Data Release 1 | milestone | 0d | 2014-09-04 | 2014-09-04 | 6 |  |  |
| 8 | Third Supercam Observing Run at HHT |  |  | 2014-11-03 | 2014-12-05 | 6 | must start on 2014-11-01 | 200h |
| 9 | Third run data processing |  |  | 2014-12-08 | 2015-02-27 | 8 |  | 480h |
| 10 | Fourth Supercam Observing Run at HHT |  |  | 2015-03-02 | 2015-04-03 |  | must start on 2015-03-01 | 200h |
| 11 | Fourth run data processing |  |  | 2015-04-06 | 2015-09-21 | 10 |  | 968h |
| 12 | Data Release 2 | milestone | 0d | 2015-09-21 | 2015-09-21 | 11 |  |  |
| 13 | Follow-up HCO+ Supercam observations at HHT |  |  | 2015-11-02 | 2015-11-13 | 11 | must start on 2015-11-01 | 80h |
| 14 | Final survey and ancillary data processing |  |  | 2015-11-16 | 2016-06-01 | 13 |  | 1140.5h |
| 15 | Final Data Release 3 | milestone | 0d | 2016-06-01 | 2016-06-01 | 14 |  |  |
